# UCATS Schedule_2009-10-13

Schedule from MS Project, 2009-08-31 to 2009-12-18.
NMCI

## Calendars

- Standard: Mon-Sun 08:00-12:00, 13:00-17:00.

## Schedule

| ID | WBS | Task | Type | Duration | Start | Finish | Predecessors | Total slack | Free slack | Constraint |
| --- | --- | --- | --- | --- | --- | --- | --- | --- | --- | --- |
| 1 | 1 | **Project Management** |  | 109d? | 2009-08-31 | 2009-12-18 |  | 0d |  |  |
| 2 | 1.1 | Organize Team | milestone | 0d | 2009-08-31 | 2009-08-31 |  | 0d |  | finish no earlier than 2009-08-31 |
| 3 | 1.2 | Select Concept |  | 4d | 2009-09-01 | 2009-09-04 | 2 | 0d |  |  |
| 4 | 1.3 | **Generate Project Proposal** |  | 10d | 2009-09-05 | 2009-09-14 | 3 | 0d |  |  |
| 5 | 1.3.1 | Project Proposal Presentation |  | 9d | 2009-09-05 | 2009-09-13 |  | 0d |  |  |
| 6 | 1.3.2 | Project Proposal Summary |  | 9d | 2009-09-05 | 2009-09-13 |  | 0d |  |  |
| 7 | 1.3.3 | Proposal Scoped and Approved | milestone | 0d | 2009-09-14 | 2009-09-14 | 5FS+1d, 6FS+1d | 0d |  |  |
| 8 | 1.4 | Project Management Plan |  | 8d | 2009-09-05 | 2009-09-12 | 3 | 89d | 0d |  |
| 9 | 1.5 | Networked Schedule |  | 8d | 2009-09-13 | 2009-09-20 | 8 | 89d |  |  |
| 10 | 1.6 | System Business Concept |  | 9d? | 2009-09-15 | 2009-09-23 | 7 | 0d |  |  |
| 11 | 1.7 | Stakeholder Value Mapping |  | 8d? | 2009-09-15 | 2009-09-22 |  | 87d |  | start no earlier than 2009-09-15 |
| 12 | 1.8 | SOW |  | 8d? | 2009-09-15 | 2009-09-22 |  | 87d |  | start no earlier than 2009-09-15 |
| 13 | 1.9 | **Reporting** |  | 84d | 2009-09-25 | 2009-12-18 |  | 0d |  |  |
| 14 | 1.9.1 | **Final Presentation** |  | 63d | 2009-10-17 | 2009-12-18 |  | 0d |  |  |
| 15 | 1.9.1.1 | Rough Draft Presentation |  | 28d | 2009-10-17 | 2009-11-13 | 74 | 0d |  |  |
| 16 | 1.9.1.2 | Final Draft Presentation |  | 35d | 2009-11-14 | 2009-12-18 | 15 | 0d |  |  |
| 17 | 1.9.2 | **Final Report** |  | 63d | 2009-10-17 | 2009-12-18 |  | 0d |  |  |
| 18 | 1.9.2.1 | Rough Draft Report |  | 28d | 2009-10-17 | 2009-11-13 | 74 | 0d |  |  |
| 19 | 1.9.2.2 | Final Draft Report |  | 35d | 2009-11-14 | 2009-12-18 | 18 | 0d |  |  |
| 20 | 1.9.3 | **Reviews** |  | 83d | 2009-09-25 | 2009-12-18 |  | 1d |  |  |
| 21 | 1.9.3.1 | SRR | milestone | 0d | 2009-09-25 | 2009-09-25 | 45 | 84d |  |  |
| 22 | 1.9.3.2 | CDR | milestone | 0d | 2009-12-18 | 2009-12-18 |  | 1d |  | start no earlier than 2009-12-18 |
| 23 | 2 | **Systems Engineering Management** |  | 21d? | 2009-09-15 | 2009-10-05 | 7 | 74d |  |  |
| 24 | 2.1 | Systems Engineering Tools Selection |  | 1d? | 2009-09-15 | 2009-09-15 |  | 94d |  |  |
| 25 | 2.2 | CM |  | 1d? | 2009-09-15 | 2009-09-15 |  | 94d |  |  |
| 26 | 2.3 | Systems Engineering Management Plan (SEMP) |  | 21d? | 2009-09-15 | 2009-10-05 |  | 74d |  | finish no earlier than 2009-10-05 |
| 27 | 2.4 | Risk Management Plan (RMP) |  | 21d? | 2009-09-15 | 2009-10-05 |  | 74d |  | finish no earlier than 2009-10-05 |
| 28 | 2.5 | Product Assurance Plan (PAP) |  | 21d? | 2009-09-15 | 2009-10-05 |  | 74d |  | finish no earlier than 2009-10-05 |

| ID | WBS | Task | Type | Duration | Start | Finish | Predecessors | Total slack | Free slack | Constraint |
| --- | --- | --- | --- | --- | --- | --- | --- | --- | --- | --- |
| 29 | 3 | **System Design** |  | 32d? | 2009-09-15 | 2009-10-16 |  | 5d |  |  |
| 30 | 3.1 | **Define System Level Design Problem** |  | 12d? | 2009-09-15 | 2009-09-26 | 7 | 5d |  |  |
| 31 | 3.1.1 | Develop Concept of Operation |  | 2d | 2009-09-15 | 2009-09-16 |  | 5d | 0d |  |
| 32 | 3.1.2 | **Develop External Systems Diagram** |  | 2d | 2009-09-15 | 2009-09-16 |  | 93d |  |  |
| 33 | 3.1.2.1 | Identify External Interface Requirements |  | 2d | 2009-09-15 | 2009-09-16 |  | 93d |  |  |
| 34 | 3.1.3 | Develop External Systems Activity Diagram |  | 9d? | 2009-09-15 | 2009-09-23 |  | 86d |  | finish no earlier than 2009-09-23 |
| 35 | 3.1.4 | Develop External Systems Diagram |  | 2d? | 2009-09-15 | 2009-09-16 |  | 5d | 0d | finish no earlier than 2009-09-16 |
| 36 | 3.1.5 | Develop Systems Objectives Hierarchy |  | 2d | 2009-09-15 | 2009-09-16 |  | 93d |  |  |
| 37 | 3.1.6 | **Develop Analyze and Refine Requirements** |  | 9d | 2009-09-17 | 2009-09-25 | 35 | 5d |  |  |
| 38 | 3.1.6.1 | Develop Use Cases for CONOPs |  | 1d | 2009-09-17 | 2009-09-17 | 31 | 5d | 0d |  |
| 39 | 3.1.6.2 | Develop Sequence Diagrams for Use Cases |  | 1d | 2009-09-18 | 2009-09-18 | 38 | 5d |  |  |
| 40 | 3.1.6.3 | Develop Communications Diagram |  | 1d | 2009-09-18 | 2009-09-18 | 38 | 5d |  |  |
| 41 | 3.1.6.4 | Systems Objectives Hierarchy |  | 1d | 2009-09-18 | 2009-09-18 | 38 | 5d |  |  |
| 42 | 3.1.6.5 | Define Draft Requirements |  | 1d | 2009-09-24 | 2009-09-24 | 38, 39, 40, 41, 10 | 0d |  |  |
| 43 | 3.1.6.6 | Define Qualification Requirements |  | 1d | 2009-09-18 | 2009-09-18 | 38 | 91d |  |  |
| 44 | 3.1.6.7 | Ensure Requirements Feasibility |  | 1d | 2009-09-25 | 2009-09-25 | 42 | 0d |  |  |
| 45 | 3.1.7 | Obtain Approval for Requirements | milestone | 0d | 2009-09-25 | 2009-09-25 | 44 | 0d |  |  |
| 46 | 3.1.8 | Document Final Requirements |  | 1d | 2009-09-26 | 2009-09-26 | 45 | 0d |  |  |
| 47 | 3.2 | **Develop System Functional Architecture** |  | 7d | 2009-09-27 | 2009-10-03 | 7 | 0d |  |  |
| 48 | 3.2.1 | Create Simple Functional Concept |  | 1d | 2009-09-27 | 2009-09-27 | 46 | 0d |  |  |
| 49 | 3.2.2 | **Draft and Evaluate Functional Model** |  | 3d | 2009-09-28 | 2009-09-30 |  | 0d |  |  |
| 50 | 3.2.2.1 | Conduct Functional Decomposition Brainstorming |  | 1d | 2009-09-28 | 2009-09-28 | 48 | 0d |  |  |
| 51 | 3.2.2.2 | Conduct Functional Decomposition Trade-Study |  | 1d | 2009-09-29 | 2009-09-29 | 50 | 0d |  |  |
| 52 | 3.2.2.3 | Select Functional Decomposition |  | 1d | 2009-09-30 | 2009-09-30 | 51 | 0d |  |  |

| ID | WBS | Task | Type | Duration | Start | Finish | Predecessors | Total slack |
| --- | --- | --- | --- | --- | --- | --- | --- | --- |
| 53 | 3.2.3 | **Complete Functional and Data Models** |  | 1d | 2009-10-01 | 2009-10-01 |  | 0d |
| 54 | 3.2.3.1 | Generate Initial Functional Model |  | 1d | 2009-10-01 | 2009-10-01 | 52 | 0d |
| 55 | 3.2.3.2 | Generate Activity Diagrams |  | 1d | 2009-10-01 | 2009-10-01 | 52 | 0d |
| 56 | 3.2.3.3 | Identify Draft Sub-System Interface Requirements |  | 1d | 2009-10-01 | 2009-10-01 | 52 | 0d |
| 57 | 3.2.4 | **Trace Input / Output Requirements** |  | 1d | 2009-10-02 | 2009-10-02 | 53 | 0d |
| 58 | 3.2.4.1 | Complete Draft IDEF A0 Diagram |  | 1d | 2009-10-02 | 2009-10-02 |  | 0d |
| 59 | 3.2.5 | Obtain Approval for Functional Architecture | milestone | 0d | 2009-10-02 | 2009-10-02 | 58 | 0d |
| 60 | 3.2.6 | Document Final Functional Architecture |  | 1d | 2009-10-03 | 2009-10-03 | 59 | 0d |
| 61 | 3.3 | **Develop System Instantiatedl Architecture** |  | 13d? | 2009-10-04 | 2009-10-16 | 7 | 0d |
| 62 | 3.3.1 | **Develop Generic Architecture** |  | 3d | 2009-10-04 | 2009-10-06 |  | 0d |
| 63 | 3.3.1.1 | Brainstorm Architecture |  | 1d | 2009-10-04 | 2009-10-04 | 60 | 0d |
| 64 | 3.3.1.2 | Generate Trade-Off Analysis |  | 1d | 2009-10-05 | 2009-10-05 | 63 | 0d |
| 65 | 3.3.1.3 | Down-Select Generic Architecture |  | 1d | 2009-10-06 | 2009-10-06 | 64 | 0d |
| 66 | 3.3.2 | **Develop Instantiated Architecture** |  | 9d | 2009-10-07 | 2009-10-15 |  | 0d |
| 67 | 3.3.2.1 | Brainstorm Instantiated Architecture Components |  | 1d | 2009-10-07 | 2009-10-07 | 65 | 0d |
| 68 | 3.3.2.2 | Generate Morphological Box - Instantiated Arch Sub-Sys |  | 2d | 2009-10-08 | 2009-10-09 | 67 | 0d |
| 69 | 3.3.2.3 | Conduct Sub-System Trade-Off Analysis |  | 3d | 2009-10-10 | 2009-10-12 | 68 | 0d |
| 70 | 3.3.2.4 | Down Select Instantiated Architecture |  | 1d | 2009-10-13 | 2009-10-13 | 69 | 0d |
| 71 | 3.3.2.5 | Finalize Sub-System Interface Requirements |  | 1d | 2009-10-14 | 2009-10-14 | 70 | 0d |
| 72 | 3.3.2.6 | Document Instantiated Draft Design |  | 1d | 2009-10-15 | 2009-10-15 | 71 | 0d |
| 73 | 3.3.3 | Obtain Approval for Instantiated Design | milestone | 0d | 2009-10-15 | 2009-10-15 | 72 | 0d |
| 74 | 3.3.4 | Final Instantiated Design |  | 1d? | 2009-10-16 | 2009-10-16 | 73 | 0d |
| 75 | 4 | **Refine / Update Design** |  | 60d | 2009-10-17 | 2009-12-15 | 74 | 3d |
| 76 | 4.1 | System Requirements |  | 60d | 2009-10-17 | 2009-12-15 |  | 3d |
| 77 | 4.2 | Functional Design |  | 60d | 2009-10-17 | 2009-12-15 |  | 3d |
| 78 | 4.3 | Instantiated Design |  | 60d | 2009-10-17 | 2009-12-15 |  | 3d |
