# UCATS Schedule_2009-10-13_Tracking

Schedule from MS Project, 2009-08-31 to 2009-12-18, A marks actual dates.
NMCI

## Calendars

- Standard: Mon-Sun 08:00-12:00, 13:00-17:00.

## Schedule

| ID | WBS | Task | Type | Duration | Start | Finish | Predecessors | Complete | Remaining | Total slack | Constraint |
| --- | --- | --- | --- | --- | --- | --- | --- | --- | --- | --- | --- |
| 1 | 1 | **Project Management** |  | 109d? | 2009-08-31 A | 2009-12-18 |  | 98% | 2.67d? | 0d |  |
| 2 | 1.1 | Organize Team |  | 1d | 2009-08-31 A | 2009-08-31 A |  | 100% |  |  | finish no earlier than 2009-08-31 |
| 3 | 1.2 | Select Concept |  | 4d | 2009-08-31 A | 2009-09-03 A | 2 | 100% |  |  |  |
| 4 | 1.3 | **Generate Project Proposal** |  | 10d | 2009-09-04 A | 2009-09-13 A | 3 | 100% |  |  |  |
| 5 | 1.3.1 | Project Proposal Presentation |  | 9d | 2009-09-04 A | 2009-09-12 A |  | 100% |  |  |  |
| 6 | 1.3.2 | Project Proposal Summary |  | 9d | 2009-09-04 A | 2009-09-12 A |  | 100% |  |  |  |
| 7 | 1.3.3 | Proposal Scoped and Approved | milestone | 0d | 2009-09-13 A | 2009-09-13 A | 5FS+1d, 6FS+1d | 100% |  |  |  |
| 8 | 1.4 | Project Management Plan |  | 7d | 2009-09-08 A | 2009-09-14 A | 3 | 100% |  |  |  |
| 9 | 1.5 | Networked Schedule |  | 7d | 2009-09-08 A | 2009-09-14 A | 8 | 100% |  |  |  |
| 10 | 1.6 | System Business Concept |  | 9d? | 2009-09-14 A | 2009-09-22 | 7 | 50% | 4.5d? | 86d |  |
| 11 | 1.7 | Stakeholder Value Mapping |  | 5d? | 2009-09-25 A | 2009-09-29 A |  | 100% |  |  | start no earlier than 2009-09-15 |
| 12 | 1.8 | SOW |  | 7d? | 2009-09-16 A | 2009-09-22 A |  | 100% |  |  | start no earlier than 2009-09-15 |
| 13 | 1.9 | **Reporting** |  | 84d | 2009-09-24 A | 2009-12-18 A |  | 100% |  |  |  |
| 14 | 1.9.1 | **Final Presentation** |  | 63d | 2009-10-16 A | 2009-12-17 A |  | 100% |  |  |  |
| 15 | 1.9.1.1 | Rough Draft Presentation |  | 28d | 2009-10-16 A | 2009-11-12 A | 71 | 100% |  |  |  |
| 16 | 1.9.1.2 | Final Draft Presentation |  | 35d | 2009-11-13 A | 2009-12-17 A | 15 | 100% |  |  |  |
| 17 | 1.9.2 | **Final Report** |  | 63d | 2009-10-16 A | 2009-12-17 A |  | 100% |  |  |  |
| 18 | 1.9.2.1 | Rough Draft Report |  | 28d | 2009-10-16 A | 2009-11-12 A | 71 | 100% |  |  |  |
| 19 | 1.9.2.2 | Final Draft Report |  | 35d | 2009-11-13 A | 2009-12-17 A | 18 | 100% |  |  |  |
| 20 | 1.9.3 | **Reviews** |  | 84d | 2009-09-24 A | 2009-12-18 A |  | 100% |  |  |  |
| 21 | 1.9.3.1 | SRR | milestone | 0d | 2009-09-24 A | 2009-09-24 A | 42 | 100% |  |  |  |
| 22 | 1.9.3.2 | CDR | milestone | 0d | 2009-12-18 A | 2009-12-18 A |  | 100% |  |  | start no earlier than 2009-12-18 |
| 23 | 2 | **Systems Engineering Management** |  | 29d? | 2009-09-14 A | 2009-10-12 | 7 | 91% | 2.65d? | 66d |  |
| 24 | 2.1 | Systems Engineering Tools Selection |  | 1d? | 2009-09-14 A | 2009-09-14 A |  | 100% |  |  |  |
| 25 | 2.2 | CM |  | 1d? | 2009-09-14 A | 2009-09-14 A |  | 100% |  |  |  |
| 26 | 2.3 | Systems Engineering Management Plan (SEMP) |  | 21d? | 2009-09-22 A | 2009-10-12 |  | 80% | 4.2d? | 66d | finish no earlier than 2009-10-05 |
| 27 | 2.4 | Risk Management Plan (RMP) |  | 12d? | 2009-09-25 A | 2009-10-06 A |  | 100% |  |  | finish no earlier than 2009-10-05 |
| 28 | 2.5 | Product Assurance Plan (PAP) |  | 11d? | 2009-09-25 A | 2009-10-05 A |  | 100% |  |  | finish no earlier than 2009-10-05 |

Notes:
- 21: SRR

| ID | WBS | Task | Type | Duration | Start | Finish | Predecessors | Complete | Remaining | Total slack | Free slack | Constraint |
| --- | --- | --- | --- | --- | --- | --- | --- | --- | --- | --- | --- | --- |
| 29 | 3 | **System Design** |  | 33d? | 2009-09-13 A | 2009-10-15 |  | 89% | 3.62d? | 63d |  |  |
| 30 | 3.1 | **Define System Level Design Problem** |  | 25d? | 2009-09-13 A | 2009-10-07 | 7 | 99% | 0.28d? | 71d |  |  |
| 31 | 3.1.1 | Develop Concept of Operation |  | 25d | 2009-09-13 A | 2009-10-07 A |  | 100% |  |  |  |  |
| 32 | 3.1.2 | **Develop External Systems Diagram** |  | 9d | 2009-09-27 A | 2009-10-05 A |  | 100% |  |  |  |  |
| 33 | 3.1.2.1 | Identify External Interface Requirements |  | 9d | 2009-09-27 A | 2009-10-05 A |  | 100% |  |  |  |  |
| 34 | 3.1.3 | Develop External Systems Activity Diagram |  | 9d? | 2009-09-27 A | 2009-10-05 A |  | 100% |  |  |  | finish no earlier than 2009-09-23 |
| 35 | 3.1.4 | Develop External Systems Diagram |  | 9d? | 2009-09-27 A | 2009-10-05 A |  | 100% |  |  |  | finish no earlier than 2009-09-16 |
| 36 | 3.1.5 | Develop Systems Objectives Hierarchy |  | 2d | 2009-09-14 A | 2009-09-15 A |  | 100% |  |  |  |  |
| 37 | 3.1.6 | **Develop Analyze and Refine Requirements** |  | 20d | 2009-09-16 A | 2009-10-05 A | 35 | 100% |  |  |  |  |
| 38 | 3.1.6.1 | Develop Use Cases for CONOPs |  | 20d | 2009-09-16 A | 2009-10-05 A | 31 | 100% |  |  |  |  |
| 39 | 3.1.6.2 | Define Draft Requirements |  | 6d | 2009-09-18 A | 2009-09-23 A | 38, 10 | 100% |  |  |  |  |
| 40 | 3.1.6.3 | Define Qualification Requirements |  | 6d | 2009-09-18 A | 2009-09-23 A | 38 | 100% |  |  |  |  |
| 41 | 3.1.6.4 | Ensure Requirements Feasibility |  | 1d | 2009-09-24 A | 2009-09-24 A | 39 | 100% |  |  |  |  |
| 42 | 3.1.7 | Obtain Approval for Requirements | milestone | 0d | 2009-09-24 | 2009-09-24 | 41 |  |  | 83d | 0d |  |
| 43 | 3.1.8 | Document Final Requirements |  | 1d | 2009-09-25 | 2009-09-25 | 42 |  |  | 83d |  |  |
| 44 | 3.2 | **Develop System Functional Architecture** |  | 26.5d | 2009-09-16 A | 2009-10-12 | 7 | 94% | 1.6d | 66.5d |  |  |
| 45 | 3.2.1 | Create Simple Functional Concept |  | 1d | 2009-09-26 A | 2009-09-26 A | 43 | 100% |  |  |  |  |
| 46 | 3.2.2 | **Draft and Evaluate Functional Model** |  | 25d | 2009-09-16 A | 2009-10-10 A |  | 100% |  |  |  |  |
| 47 | 3.2.2.1 | Conduct Functional Decomposition Brainstorming |  | 8d | 2009-09-16 A | 2009-09-23 A | 45 | 100% |  |  |  |  |
| 48 | 3.2.2.2 | Conduct Functional Decomposition Trade-Study |  | 14d | 2009-09-27 A | 2009-10-10 A | 47 | 100% |  |  |  |  |
| 49 | 3.2.2.3 | Select Functional Decomposition |  | 1d | 2009-10-10 A | 2009-10-10 A | 48 | 100% |  |  |  |  |
| 50 | 3.2.3 | **Complete Functional and Data Models** |  | 11.25d | 2009-09-30 A | 2009-10-11 |  | 83% | 1.88d | 66.5d | 0d |  |
| 51 | 3.2.3.1 | Generate Initial Functional Model |  | 1d | 2009-09-30 A | 2009-09-30 A | 49 | 100% |  |  |  |  |
| 52 | 3.2.3.2 | Generate Activity Diagrams |  | 1d | 2009-09-30 A | 2009-10-11 | 49 | 75% | 0.25d | 66.5d |  |  |
| 53 | 3.2.3.3 | Identify Draft Sub-System Interface Requirements |  | 1d | 2009-09-30 A | 2009-10-11 | 49 | 75% | 0.25d | 66.5d |  |  |

| ID | WBS | Task | Type | Duration | Start | Finish | Predecessors | Complete | Remaining | Total slack | Free slack |
| --- | --- | --- | --- | --- | --- | --- | --- | --- | --- | --- | --- |
| 54 | 3.2.4 | **Trace Input / Output Requirements** |  | 10.5d | 2009-10-01 A | 2009-10-11 | 50 | 75% | 2.62d | 66.5d |  |
| 55 | 3.2.4.1 | Complete Draft IDEF A0 Diagram |  | 1d | 2009-10-01 A | 2009-10-11 |  | 75% | 0.25d | 66.5d | 0d |
| 56 | 3.2.5 | Obtain Approval for Functional Architecture | milestone | 0d | 2009-10-11 | 2009-10-11 | 55 |  |  | 66.5d | 0d |
| 57 | 3.2.6 | Document Final Functional Architecture |  | 1d | 2009-10-11 | 2009-10-12 | 56 |  |  | 66.5d |  |
| 58 | 3.3 | **Develop System Instantiatedl Architecture** |  | 13d? | 2009-10-03 A | 2009-10-15 | 7 | 12% | 11.5d? | 3d |  |
| 59 | 3.3.1 | **Develop Generic Architecture** |  | 3d | 2009-10-03 A | 2009-10-05 |  | 50% | 1.5d | 0d |  |
| 60 | 3.3.1.1 | Brainstorm Architecture |  | 1d | 2009-10-03 A | 2009-10-03 A | 57 | 100% |  |  |  |
| 61 | 3.3.1.2 | Generate Trade-Off Analysis |  | 1d | 2009-10-04 A | 2009-10-04 | 60 | 50% | 0.5d | 0d |  |
| 62 | 3.3.1.3 | Down-Select Generic Architecture |  | 1d | 2009-10-05 | 2009-10-05 | 61 |  |  | 0d |  |
| 63 | 3.3.2 | **Develop Instantiated Architecture** |  | 9d | 2009-10-06 | 2009-10-14 |  |  |  | 0d |  |
| 64 | 3.3.2.1 | Brainstorm Instantiated Architecture Components |  | 1d | 2009-10-06 | 2009-10-06 | 62 |  |  | 0d |  |
| 65 | 3.3.2.2 | Generate Morphological Box - Instantiated Arch Sub-Sys |  | 2d | 2009-10-07 | 2009-10-08 | 64 |  |  | 0d |  |
| 66 | 3.3.2.3 | Conduct Sub-System Trade-Off Analysis |  | 3d | 2009-10-09 | 2009-10-11 | 65 |  |  | 0d |  |
| 67 | 3.3.2.4 | Down Select Instantiated Architecture |  | 1d | 2009-10-12 | 2009-10-12 | 66 |  |  | 0d |  |
| 68 | 3.3.2.5 | Finalize Sub-System Interface Requirements |  | 1d | 2009-10-13 | 2009-10-13 | 67 |  |  | 0d |  |
| 69 | 3.3.2.6 | Document Instantiated Draft Design |  | 1d | 2009-10-14 | 2009-10-14 | 68 |  |  | 0d |  |
| 70 | 3.3.3 | Obtain Approval for Instantiated Design | milestone | 0d | 2009-10-14 A | 2009-10-14 | 69 | 25% | 0d | 3d | 0d |
| 71 | 3.3.4 | Final Instantiated Design |  | 1d? | 2009-10-15 | 2009-10-15 | 70 |  |  | 3d | 0d |
| 72 | 4 | **Refine / Update Design** |  | 60d | 2009-10-16 | 2009-12-14 | 71 |  |  | 3d |  |
| 73 | 4.1 | System Requirements |  | 60d | 2009-10-16 | 2009-12-14 |  |  |  | 3d |  |
| 74 | 4.2 | Functional Design |  | 60d | 2009-10-16 | 2009-12-14 |  |  |  | 3d |  |
| 75 | 4.3 | Instantiated Design |  | 60d | 2009-10-16 | 2009-12-14 |  |  |  | 3d |  |
